Schedule from MS Project, 2016-08-08 to 2016-09-03.
Microsoft

## Calendars

- Standard: Mon-Fri 08:00-12:00, 13:00-17:00; Sat-Sun off. Exceptions (off unless hours are given): 2016-08-21 08:00-12:00, 13:00-17:00.

## Resources

| Resource |
| --- |
| Vacuum |
| Software |
| Francis |
| Delacruz |
| Norris |
| Ketchum |
| Kortze |
| RF |
| MIT |
| JLAB |
| JLAB/MIT |
| Install. |
| Install |
| DCP/ I&C |
| Install/ DCP |
| S&A |
| Bates |
| Bates/ JLAB |
| Bates/ Vacuum |
| ? |
| Bates/ MIT |

## Schedule

| ID | WBS | Task | Type | Duration | Start | Finish | Predecessors | Total slack | Free slack | Constraint | Resources | Work |
| --- | --- | --- | --- | --- | --- | --- | --- | --- | --- | --- | --- | --- |
| 1 | 1 | **Detector System Installation Begins** |  | 10d | 2016-08-08 | 2016-08-19 |  |  |  |  |  |  |
| 2 | 1.1 | Break 4F Sub Region 3 vacuum |  | 1d? | 2016-08-08 | 2016-08-08 |  | 0d |  |  | Vacuum | 8h |
| 3 | 1.2 | Remove Solenoid fom Beamline |  | 1d | 2016-08-09 | 2016-08-09 | 2 | 0d |  | start no earlier than 2016-08-08 | Install | 8h |
| 4 | 1.3 | P&I Installation | manual | 5d | 2016-08-09 | 2016-08-15 | 3 |  |  | start no earlier than 2016-08-09 | Bates | 40h |
| 5 | 1.4 | Detector/ Target Installation | manual | 5d | 2016-08-09 | 2016-08-15 | 3 |  |  | start no earlier than 2016-08-09 | MIT | 40h |
| 7 | 2 | **Install 3F07 BPM** |  | 2d | 2016-08-11 | 2016-08-12 |  | 0d | 1d |  |  |  |
| 8 | 2.1 | Pumpdown 3F line |  | 1d? | 2016-08-12 | 2016-08-12 |  | 0d |  | start no earlier than 2016-08-12 | Vacuum | 8h |
| 9 | 2.2 | Reinstall Correctors/ BPM cables |  | 1d? | 2016-08-12 | 2016-08-12 |  | 0d |  | start no earlier than 2016-08-12 | DCP/ I&C | 8h |
| 11 | 3 | **Beamline Sub Region 3** |  | 3d | 2016-08-15 | 2016-08-17 | 5, 4 |  |  |  | Bates/ Vacuum | 24h |
| 12 | 3.1 | Move Solenoid into Beamline and connect |  | 1d? | 2016-08-15 | 2016-08-15 |  | 0d |  |  | Install | 8h |
| 13 | 3.2 | Reconnect Power/ Interlocks/LCW |  | 2d? | 2016-08-15 | 2016-08-16 |  | 0d |  | finish no earlier than 2016-08-16 | Install/ DCP | 16h |
| 14 | 3.3 | Begin Sub Region 3 Pumpdown |  | 2d? | 2016-08-16 | 2016-08-17 | 12 | 0d |  |  |  |  |
| 15 | 3.4 | Sub Region 3 Leak Test |  | 2d? | 2016-08-16 | 2016-08-17 | 14 | 0d |  | finish no earlier than 2016-08-17 | JLAB/MIT | 16h |
| 16 | 3.5 | Survey and Alignment | manual | 2d | 2016-08-16 | 2016-08-17 | 12 |  |  | start no earlier than 2016-08-16 | S&A | 16h |
| 17 | 3.6 | Install Dump Shielding |  | 3d? | 2016-08-17 | 2016-08-19 |  | 0d |  | finish no earlier than 2016-08-19 |  |  |
| 19 | 4 | **Gas Systems Installation** |  | 5d | 2016-08-15 | 2016-08-19 |  | 0d |  |  |  |  |
| 20 | 4.1 | Install Hydrogen Line |  | 4d? | 2016-08-15 | 2016-08-18 |  | 0d |  | finish no earlier than 2016-08-18 | Install | 32h |
| 21 | 4.2 | Install N2 line |  | 3d? | 2016-08-15 | 2016-08-17 |  | 0d |  | finish no earlier than 2016-08-17 | Install | 24h |
| 22 | 4.3 | Install vent line |  | 2d? | 2016-08-15 | 2016-08-16 |  | 0d |  | finish no earlier than 2016-08-16 | Install | 16h |
| 23 | 4.4 | Systems Checkout |  | 2d? | 2016-08-18 | 2016-08-19 |  | 0d |  | finish no earlier than 2016-08-19 | ? | 16h |
| 25 | 5 | **Detector/ P&I Checkout** |  | 4d | 2016-08-16 | 2016-08-19 |  | 0d |  |  |  |  |
| 26 | 5.1 | Process and Instrumentation Checkout | manual | 4d | 2016-08-16 | 2016-08-19 | 14, 23 |  |  | start no earlier than 2016-08-16 | Bates | 32h |
| 27 | 5.2 | Target/ Detector Checkout |  | 4d? | 2016-08-16 | 2016-08-19 | 14 | 0d |  | finish no earlier than 2016-08-19 | MIT | 32h |
| 29 | 6 | LERF Systems HCO |  | 2d? | 2016-08-18 | 2016-08-19 | 16 | 0d |  |  | JLAB | 16h |
| 31 | 7 | RF Systems Soak (Opportunistic Swing Shifts) | manual | 8d | 2016-08-09 | 2016-08-18 |  |  |  |  | RF | 64h |
| 33 | 8 | Ready for Operations |  | 1d | 2016-08-21 | 2016-08-21 | 29, 25 | 0d |  |  | Bates/ MIT | 8h |
| 35 | 9 | Beam Ops |  | 2w | 2016-08-22 | 2016-09-03 | 33 | 0d |  |  |  |  |
| 37 | 10 | Moller Dump Installation (Opportunistic) |  | 2d | 2016-08-19 | 2016-08-21 |  | 0d |  | start no earlier than 2016-08-19 | MIT | 16h |
| 39 | 11 | Dump Viewer Installation (Opportunistic) |  | 2d? | 2016-08-19 | 2016-08-21 |  | 0d |  | finish no earlier than 2016-08-21 | JLAB | 16h |
